# Target Hall Scheduled Activities,Apr 07-June 26 2015

Schedule from MS Project, 2015-04-07 to 2015-07-24, A marks actual dates.

## Calendars

- Standard: Mon-Fri 08:00-12:00, 13:00-17:00; Sat-Sun off.

## Resources

| Resource |
| --- |
| D.Wang |
| T.Cave |
| A.Mjos |
| C.Fisher |
| D.McDonald |
| RPG |
| ISAC Opps |
| M.Dalla Valle |
| K.Ng |
| G.Minor |
| D.Jackson |
| I.Earle |

## Schedule

| ID | WBS | Task | Duration | Start | Finish | Predecessors | Complete | Remaining | Total slack | Free slack | Constraint | Resources | Work | Actual work |
| --- | --- | --- | --- | --- | --- | --- | --- | --- | --- | --- | --- | --- | --- | --- |
| 1 | 1 | **TM4 Ta#45 ready for Beam at ITE** | 4d | 2015-04-07 08:00 A | 2015-04-10 17:00 A |  | 100% |  |  |  |  |  | 32h | 32h |
| 2 | 1.1 | Grounding Test-ITW, ITE | 1d | 2015-04-07 08:00 A | 2015-04-07 17:00 A |  | 100% |  |  |  |  | ISAC Opps | 8h | 8h |
| 3 | 1.2 | Foot Anchors Grout-ITW, ITE Handrails | 2.5d | 2015-04-08 08:00 A | 2015-04-10 12:00 A | 2 | 100% |  |  |  |  | M.Dalla Valle; D.McDonald; D.Wang | 20h | 20h |
| 4 | 1.3 | Shielding Blocks Move-ITW to ITE | 0.5d | 2015-04-10 13:00 A | 2015-04-10 17:00 A | 3 | 100% |  |  |  |  | D.Wang; D.McDonald | 4h | 4h |
| 5 | 2 | **TM1-TM2-TM4 Target Hall Activities** | 75d | 2015-04-13 08:00 A | 2015-07-24 17:00 |  | 68% | 23.76d | 0d |  |  |  | 731.6h | 505.6h |
| 6 | 2.1 | **TM1 UCx Ready for Beam at ITW** | 8d | 2015-04-17 08:00 A | 2015-04-28 17:00 A |  | 100% |  |  |  |  |  | 85.6h | 85.6h |
| 7 | 2.1.1 | New Ucx Target in SHC/Cameras set up | 0.2d | 2015-04-17 08:00 A | 2015-04-17 09:36 A |  | 100% |  |  |  | start no earlier than 2015-04-17 08:00 | A.Mjos; I.Earle; T.Cave | 4.8h | 4.8h |
| 8 | 2.1.2 | Moduel Move-TM1-Silo to SHC | 0.2d | 2015-04-17 09:36 A | 2015-04-17 11:12 A | 7 | 100% |  |  |  | start no earlier than 2015-04-16 08:00 | T.Cave; D.Wang | 3.2h | 3.2h |
| 9 | 2.1.3 | Ucx target install /Leak , Electrical Check at SHC | 0.2d | 2015-04-17 11:12 A | 2015-04-17 13:48 A | 8 | 100% |  |  |  | start no earlier than 2015-04-16 08:00 | I.Earle; T.Cave; D.Wang | 4.8h | 4.8h |
| 10 | 2.1.4 | Module Move- TM1 -SHC to CS | 0.2d | 2015-04-17 13:48 A | 2015-04-17 15:24 A | 9 | 100% |  |  |  | start no earlier than 2015-04-16 08:00 | D.Wang; T.Cave | 3.2h | 3.2h |
| 11 | 2.1.5 | TM1 Vacuum Connect at CS/ CS Pump Down | 0.2d | 2015-04-17 15:24 A | 2015-04-17 17:00 A | 10 | 100% |  |  |  | start no earlier than 2015-04-16 08:00 | D.Wang | 1.6h | 1.6h |
| 12 | 2.1.6 | Heium Pressure Test-TM1 HS line at CS | 0.5d | 2015-04-20 08:00 A | 2015-04-20 12:00 A | 11 | 100% |  |  |  |  | D.Wang | 4h | 4h |
| 13 | 2.1.7 | TM1 Connect at CS/HV Cover Installed | 0.5d | 2015-04-20 13:00 A | 2015-04-20 17:00 A | 12 | 100% |  |  |  | start no earlier than 2015-04-17 08:00 | D.Wang; D.McDonald | 8h | 8h |
| 14 | 2.1.8 | Module Conditioning-TM1 at CS | 4.5d | 2015-04-21 08:00 A | 2015-04-27 12:00 A | 13 | 100% |  |  |  | start no earlier than 2015-04-20 08:00 | A.Mjos | 36h | 36h |
| 15 | 2.1.9 | Finish of Conditioning/Module Disconnect -TM1 at CS | 0.5d | 2015-04-27 13:00 A | 2015-04-27 17:00 A | 14 | 100% |  |  |  |  | D.Wang | 4h | 4h |
| 16 | 2.1.10 | Argon Vent CS /ITW cameras Set up/Shield Plug Move from ITW | 0.25d | 2015-04-28 08:00 A | 2015-04-28 10:00 A | 15 | 100% |  |  |  |  | D.Wang; T.Cave | 4h | 4h |
| 17 | 2.1.11 | Module Move -TM1-CS to ITW | 0.25d | 2015-04-28 10:00 A | 2015-04-28 12:00 A | 16 | 100% |  |  |  |  | D.Wang; T.Cave | 4h | 4h |
| 18 | 2.1.12 | Module Connect-TM1 at ITW/Start of Turbopumps | 0.5d | 2015-04-28 13:00 A | 2015-04-28 17:00 A | 17 | 100% |  |  |  |  | D.Wang; D.McDonald | 8h | 8h |
| 19 | 2.2 | **TM2 Refurbishment Completion** | 67d | 2015-04-13 08:00 A | 2015-07-14 17:00 |  | 63% | 24.61d | 2.25d |  |  |  | 380h | 260h |
| 20 | 2.2.1 | TM2 Top Service Cap Reconfiguration | 3d | 2015-04-13 08:00 A | 2015-04-15 17:00 A |  | 100% |  |  |  | finish no earlier than 2015-04-15 17:00 | D.Wang | 24h | 24h |
| 21 | 2.2.2 | Module Move -TM2-Silo to ITW | 1d | 2015-04-30 08:00 A | 2015-04-30 17:00 A |  | 100% |  |  |  | start no earlier than 2015-04-30 08:00 | T.Cave; D.Wang | 16h | 16h |
| 22 | 2.2.3 | TM2 Wiring Prepare/Work Area Set up in TH | 1d | 2015-05-01 08:00 A | 2015-05-01 17:00 A | 21 | 100% |  |  |  |  | D.Wang; T.Cave | 16h | 16h |
| 23 | 2.2.4 | TM2 Wiring - SHC & TM2 Service Cap | 2d | 2015-05-04 08:00 A | 2015-05-05 17:00 A | 22 | 100% |  |  |  |  | T.Cave; C.Fisher; D.Wang | 48h | 48h |
| 24 | 2.2.5 | Module Move-TM2-SHC to CS | 1d | 2015-05-27 08:00 A | 2015-05-27 17:00 A | 23 | 100% |  |  |  | start no earlier than 2015-05-27 08:00 | T.Cave; D.Wang | 16h | 16h |
| 25 | 2.2.6 | TM2 wiring-TM2 at CS | 1d | 2015-05-28 08:00 A | 2015-05-28 17:00 A | 24 | 100% |  |  |  | start no earlier than 2015-05-26 08:00 | T.Cave; D.Wang | 16h | 16h |
| 26 | 2.2.7 | Module move-TM2 -CS to Silo | 1d | 2015-05-29 08:00 A | 2015-05-29 17:00 A | 25 | 100% |  |  |  | start no earlier than 2015-05-28 08:00 | D.Wang; T.Cave | 16h | 16h |
| 27 | 2.2.8 | Source Tray Install on Transfer Table/Transfer Source Tray into SHC | 1d | 2015-06-11 08:00 A | 2015-06-11 17:00 A | 26 | 100% |  |  |  | start no earlier than 2015-06-11 08:00 | D.Wang; C.Fisher; T.Cave | 24h | 24h |
| 28 | 2.2.9 | Remove Transfer table-SHC to TH/Clean up | 0.5d | 2015-06-12 08:00 A | 2015-06-12 12:00 A | 27 | 100% |  |  |  | start no earlier than 2015-05-12 08:00 | C.Fisher; T.Cave; D.Wang | 12h | 12h |
| 29 | 2.2.10 | Module Move- TM2 -Silo to SHC | 1d | 2015-06-15 08:00 A | 2015-06-15 17:00 A |  | 100% |  |  |  | start no earlier than 2015-06-15 08:00 | T.Cave; D.Wang | 16h | 16h |
| 30 | 2.2.11 | Leak, Electrical Check-TM2 at SHC | 1d | 2015-06-24 08:00 A | 2015-06-24 17:00 A | 29 | 100% |  |  |  | start no earlier than 2015-06-22 08:00 | C.Fisher; T.Cave; D.Wang; D.Jackson | 32h | 32h |
| 31 | 2.2.12 | Module Move-TM2-SHC to CS/ Start of CS Pumps | 1d | 2015-06-26 08:00 A | 2015-06-26 17:00 A | 30 | 100% |  |  |  | start no earlier than 2015-06-26 08:00 | T.Cave; D.Wang | 16h | 16h |
| 32 | 2.2.13 | Helium Pressure Test -TM2 water lines at CS/TM2 Connnect at CS | 1d | 2015-06-29 08:00 A | 2015-06-29 17:00 A | 31 | 100% |  |  |  | start no earlier than 2015-06-24 08:00 | D.Wang | 8h | 8h |
| 33 | 2.2.14 | TM2 HV test at CS | 3d | 2015-06-30 08:00 | 2015-07-02 17:00 | 32 |  |  | 4.25d | 0d |  |  |  |  |
| 34 | 2.2.15 | Dummy Target Insert into SHC | 0.25d | 2015-07-03 08:00 | 2015-07-03 10:00 | 33 |  |  | 4.25d | 0d | start no earlier than 2015-07-03 08:00 | A.Mjos; C.Fisher | 4h |  |
| 35 | 2.2.16 | Module move-TM2- CS to SHC | 0.75d | 2015-07-03 10:00 | 2015-07-03 17:00 | 34 |  |  | 4.25d | 2d | finish no earlier than 2015-07-03 17:00 | D.Wang; T.Cave | 12h |  |
| 36 | 2.2.17 | Dummy target Installation /Leak Check ,Electrical Check | 1d | 2015-07-08 08:00 | 2015-07-08 17:00 | 35 |  |  | 2.25d | 0d | start no earlier than 2015-07-08 08:00 | C.Fisher; D.Wang; T.Cave | 24h |  |
| 37 | 2.2.18 | Module Move -TM2-SHC to CS/Start of CS Pumps | 1d | 2015-07-09 08:00 | 2015-07-09 17:00 | 36 |  |  | 2.25d | 0d | start no earlier than 2015-07-09 08:00 | D.Wang; T.Cave | 16h |  |
| 38 | 2.2.19 | Module Connect-TM2 at CS/Start of TM2 Conditioning | 1d | 2015-07-10 08:00 | 2015-07-10 17:00 | 37 |  |  | 2.25d | 0d | start no earlier than 2015-07-10 08:00 | D.Wang; A.Mjos | 16h |  |
| 39 | 2.2.20 | TM2 Test at CS with Dummy Target | 2d | 2015-07-13 08:00 | 2015-07-14 17:00 | 38 |  |  | 2.25d | 0.25d | start no earlier than 2015-07-13 08:00 | A.Mjos; D.Jackson; G.Minor | 48h |  |

| ID | WBS | Task | Duration | Start | Finish | Predecessors | Complete | Remaining | Total slack | Free slack | Constraint | Resources | Work | Actual work |
| --- | --- | --- | --- | --- | --- | --- | --- | --- | --- | --- | --- | --- | --- | --- |
| 40 | 2.3 | **TM4 HpSiC Ready for Beam at ITE** | 21d | 2015-05-22 08:00 A | 2015-06-19 17:00 A |  | 100% |  |  |  |  |  | 140h | 140h |
| 41 | 2.3.1 | Shielding Blocks Move-ITE to ITW | 1d | 2015-05-22 08:00 A | 2015-05-22 17:00 A | 18 | 100% |  |  |  | start no earlier than 2015-05-22 08:00 | D.Wang; D.McDonald | 16h | 16h |
| 42 | 2.3.2 | New HP SiC Target in SHC | 1d | 2015-06-01 08:00 A | 2015-06-01 17:00 A | 41 | 100% |  |  |  | start no earlier than 2015-06-01 08:00 | C.Fisher; A.Mjos | 16h | 16h |
| 43 | 2.3.3 | Cameras set up/Module Move-TM4 -ITE to SHC | 0.5d | 2015-06-02 08:00 A | 2015-06-02 12:00 A | 42 | 100% |  |  |  | start no earlier than 2015-06-02 08:00 | T.Cave; D.Wang | 8h | 8h |
| 44 | 2.3.4 | New SiC Target Install/Electrical,vacuum Check | 0.5d | 2015-06-02 13:00 A | 2015-06-02 17:00 A | 43 | 100% |  |  |  |  | C.Fisher; D.Wang; T.Cave | 12h | 12h |
| 45 | 2.3.5 | Module Move-TM4-SHC to CS/Start of CS Turbo Pumps | 1d | 2015-06-03 08:00 A | 2015-06-03 17:00 A | 44 | 100% |  |  |  |  | D.Wang; T.Cave | 16h | 16h |
| 46 | 2.3.6 | Spent Target Move -HPTa-SHC to Storage Vault | 0.5d | 2015-06-04 08:00 A | 2015-06-04 12:00 A | 45 | 100% |  |  |  |  | C.Fisher; T.Cave; D.Wang | 12h | 12h |
| 47 | 2.3.7 | Helium Pressure Test/Connect TM4 At CS/HV Cover on | 0.5d | 2015-06-04 08:00 A | 2015-06-04 12:00 A | 45 | 100% |  |  |  |  | D.Wang | 4h | 4h |
| 48 | 2.3.8 | Module Conditioning-TM4 at CS | 2.5d | 2015-06-04 13:00 A | 2015-06-08 17:00 A | 47 | 100% |  |  |  |  | A.Mjos | 20h | 20h |
| 49 | 2.3.9 | Finish of Conditioning/Module Disconnect -TM4 at CS | 0.5d | 2015-06-09 08:00 A | 2015-06-09 12:00 A | 48 | 100% |  |  |  |  | D.Wang | 4h | 4h |
| 50 | 2.3.10 | Module Move -TM4-CS to ITE | 0.5d | 2015-06-10 08:00 A | 2015-06-10 12:00 A | 49 | 100% |  |  |  | start no earlier than 2015-06-10 08:00 | T.Cave; D.Wang | 8h | 8h |
| 51 | 2.3.11 | Module Connect-TM4 at ITW/Start of ITE Turbopumps | 0.5d | 2015-06-10 13:00 A | 2015-06-10 17:00 A | 50 | 100% |  |  |  | start no earlier than 2015-06-10 08:00 | D.Wang; D.McDonald | 8h | 8h |
| 52 | 2.3.12 | Shielding Blocks Move-ITW to ITE/ ITE Ready for Proton Beam | 1d | 2015-06-19 08:00 A | 2015-06-19 17:00 A | 51 | 100% |  |  |  | start no earlier than 2015-06-19 08:00 | D.Wang; D.McDonald | 16h | 16h |
| 53 | 2.4 | **TM1 Phase out/TM2 ZrC Ready for Beam at ITW** | 19d | 2015-06-30 08:00 A | 2015-07-24 17:00 |  | 13% | 16.62d | 0d |  |  |  | 126h | 20h |
| 54 | 2.4.1 | Cameras Set up/Module Move-TM1 -ITW to SHC | 0.5d | 2015-06-30 08:00 A | 2015-06-30 12:00 A | 52 | 100% |  |  |  | start no earlier than 2015-06-30 08:00 | T.Cave; D.Wang; D.McDonald | 12h | 12h |
| 55 | 2.4.2 | Lp UCx Target Remove/ Electrical Check at SHC | 0.5d | 2015-06-30 13:00 A | 2015-06-30 17:00 A | 54 | 100% |  |  |  | start no earlier than 2015-06-30 08:00 | C.Fisher; T.Cave | 8h | 8h |
| 56 | 2.4.3 | Module Move- TM1 -SHC to Silo | 0.5d | 2015-07-02 08:00 | 2015-07-02 12:00 | 55 |  |  | 10d | 0d | start no earlier than 2015-07-02 08:00 | T.Cave; D.Wang | 8h |  |
| 57 | 2.4.4 | Spent Target Move -Lp UCx-SHC to Storage Vault | 0.5d | 2015-07-02 13:00 | 2015-07-02 17:00 | 56 |  |  | 10d | 8d | start no earlier than 2015-07-02 08:00 | C.Fisher; T.Cave; D.Wang | 12h |  |
| 58 | 2.4.5 | New LpZrC Target in SHC | 0.25d | 2015-07-15 08:00 | 2015-07-15 10:00 | 57 |  |  | 2d | 0d | start no earlier than 2015-07-15 08:00 | C.Fisher; A.Mjos | 4h |  |
| 59 | 2.4.6 | Module Move-TM2-CS to SHC | 0.75d | 2015-07-15 10:00 | 2015-07-15 17:00 | 58, 39 |  |  | 2d | 0d | start no earlier than 2015-07-06 08:00 | T.Cave; D.Wang | 12h |  |
| 60 | 2.4.7 | New ZrC Target Installation/ Electrical, Vacuum Check | 0.5d | 2015-07-16 08:00 | 2015-07-16 12:00 | 59 |  |  | 2d | 0d | start no earlier than 2015-07-07 08:00 | T.Cave; C.Fisher; D.Wang | 12h |  |
| 61 | 2.4.8 | Module Move -TM2-SHC to CS/Start of CS Pumps | 0.5d | 2015-07-16 13:00 | 2015-07-16 17:00 | 60 |  |  | 2d | 0d | start no earlier than 2015-07-07 08:00 | D.Wang; T.Cave | 8h |  |
| 62 | 2.4.9 | Helium Pressure Test/Connect TM2 At CS/HV Cover on | 0.25d | 2015-07-17 08:00 | 2015-07-17 10:00 | 61 |  |  | 2d | 0d | start no earlier than 2015-07-08 08:00 | D.Wang; D.McDonald | 4h |  |
| 63 | 2.4.10 | Module Conditioning-TM2 at CS | 1.75d | 2015-07-17 10:00 | 2015-07-20 17:00 | 62 |  |  | 2d | 0d | finish no earlier than 2015-07-13 17:00 | A.Mjos | 14h |  |
| 64 | 2.4.11 | Finish of Conditioning/Module Disconnect-TM2 at CS | 0.25d | 2015-07-21 08:00 | 2015-07-21 10:00 | 63 |  |  | 2d | 0d | start no earlier than 2015-07-13 08:00 | D.Wang; D.McDonald | 4h |  |
| 65 | 2.4.12 | Module Move-TM2-CS to ITW | 0.25d | 2015-07-21 10:00 | 2015-07-21 12:00 | 64 |  |  | 2d | 0d | start no earlier than 2015-07-14 08:00 | D.Wang; T.Cave | 4h |  |
| 66 | 2.4.13 | Module Connect-TM2 at ITW/Start of Turbo Pumps | 0.5d | 2015-07-21 13:00 | 2015-07-21 17:00 | 65 |  |  | 2d |  | start no earlier than 2015-07-14 08:00 | D.Wang; D.McDonald | 8h |  |
| 67 | 2.4.14 | Shielding Blocks Move- ITE to ITW | 1d | 2015-07-24 08:00 | 2015-07-24 17:00 | 66 |  |  | 0d |  | start no earlier than 2015-07-24 08:00 | D.Wang; D.McDonald | 16h |  |
